# Galway tender and delivery

Schedule from MS Project, 2026-06-16 to 2026-11-27.

## Calendars

- Standard: Mon-Fri 08:00-12:00, 13:00-17:00; Sat-Sun off.

## Schedule

| ID | WBS | Task | Type | Duration | Start | Finish | Predecessors | Total slack | Free slack | Constraint |
| --- | --- | --- | --- | --- | --- | --- | --- | --- | --- | --- |
| 1 | 1 | E-tender release | milestone | 0d | 2026-06-16 | 2026-06-16 |  | -1d | 0d | start no earlier than 2026-06-16 |
| 2 | 2 | Tender Period (30 Days) |  | 4.2w | 2026-06-16 | 2026-07-14 | 1 | -1d | 0d | finish no earlier than 2026-07-14 |
| 3 | 3 | Tender Evaluation |  | 1d | 2026-07-15 | 2026-07-15 | 2 | -1d | 0d |  |
| 4 | 4 | Contractor Negotiations |  | 3d | 2026-07-15 | 2026-07-17 | 3FS-1d | -1d | 0d |  |
| 5 | 5 | Contractor Award |  | 1d | 2026-07-20 | 2026-07-20 | 4 | -1d | 0d |  |
| 6 | 6 | Standstill Period |  | 2w | 2026-07-21 | 2026-08-03 | 5 | -1d | 0d |  |
| 7 | 7 | **Construction period** |  | 85d? | 2026-08-03 | 2026-11-27 | 6 | 0d |  |  |
| 8 | 7.1 | **Site set up** |  | 3d? | 2026-08-04 | 2026-08-06 |  | 0d |  |  |
| 9 | 7.1.1 | Site setup and welfare |  | 2d | 2026-08-04 | 2026-08-05 | 6 | 0d |  |  |
| 10 | 7.1.2 | Fire escape and crowd management coordination |  | 1d | 2026-08-05 | 2026-08-05 | 9FS-1d | 1d |  |  |
| 11 | 7.1.3 | Temporary signage |  | 1d? | 2026-08-05 | 2026-08-05 | 9FS-1d | 1d |  |  |
| 12 | 7.1.4 | All areas cordoned off as appropiate |  | 1d | 2026-08-05 | 2026-08-05 | 9FS-1d | 1d |  |  |
| 13 | 7.1.5 | Protection to retained circulation routes |  | 1d? | 2026-08-06 | 2026-08-06 | 9 | 0d |  |  |
| 14 | 7.2 | **Off-Site Manufacture** |  | 17w? | 2026-08-03 | 2026-11-27 | 6 |  |  |  |
| 15 | 7.2.1 | Recladding all 1st floor panelling | manual | 2w | 2026-08-03 | 2026-08-14 |  |  |  |  |
| 16 | 7.2.2 | New ground floor booths | manual | 6w | 2026-08-03 | 2026-09-11 |  |  |  |  |
| 17 | 7.2.3 | New bar ledges | manual | 2w | 2026-08-03 | 2026-08-14 |  |  |  |  |
| 18 | 7.2.4 | Cladding for new entrance building | manual | 2w | 2026-08-03 | 2026-08-14 |  |  |  |  |
| 19 | 7.2.5 | Cladding for all bars | manual | 2w | 2026-08-03 | 2026-08-14 |  |  |  |  |
| 20 | 7.2.6 | Recladding all panelling | manual | 2w | 2026-08-12 | 2026-08-25 | 28 |  |  |  |
| 21 | 7.2.7 | All signage and illuminated branding |  | 2w | 2026-08-03 | 2026-08-14 |  | 70d | 0d |  |
| 22 | 7.3 | **Phase 1 – First Floor Refurbishment** |  | 40d? | 2026-08-06 | 2026-09-30 | 8FS-1d | 0d |  |  |
| 23 | 7.3.1 | **Strip Out and Site Preparation** |  | 5d? | 2026-08-06 | 2026-08-12 | 8FS-1d | 0d |  |  |
| 24 | 7.3.1.1 | Remove all loose furniture |  | 1d? | 2026-08-06 | 2026-08-06 |  | 1d | 0d |  |
| 25 | 7.3.1.2 | Install temporary hoarding and dust protection |  | 1d? | 2026-08-07 | 2026-08-07 | 24 | 1d | 0d |  |
| 26 | 7.3.1.3 | Disconnect redundant services where required |  | 1d? | 2026-08-10 | 2026-08-10 | 25 | 1d | 0d |  |
| 27 | 7.3.1.4 | Remove existing flooring finishes |  | 1d? | 2026-08-11 | 2026-08-11 | 26 | 1d |  |  |
| 28 | 7.3.1.5 | Remove wall panelling for workshop refurbishment |  | 1w | 2026-08-06 | 2026-08-12 | 8FS-1d | 0d |  |  |

| ID | WBS | Task | Type | Duration | Start | Finish | Predecessors | Total slack | Free slack |
| --- | --- | --- | --- | --- | --- | --- | --- | --- | --- |
| 29 | 7.3.2 | **Demolition and Structural Alterations** |  | 5d | 2026-08-13 | 2026-08-19 | 23 | 0d |  |
| 30 | 7.3.2.1 | Substrate preparation works |  | 3d | 2026-08-13 | 2026-08-17 |  | 0d |  |
| 31 | 7.3.2.2 | Form new platforms and raised floor sections |  | 2d | 2026-08-18 | 2026-08-19 | 30 | 0d |  |
| 32 | 7.3.2.3 | Minor builders works and framing |  | 2d | 2026-08-18 | 2026-08-19 | 30 | 0d |  |
| 33 | 7.3.2.4 | Coordination of electrical and lighting alterations |  | 1w | 2026-08-13 | 2026-08-19 |  | 0d |  |
| 34 | 7.3.3 | **First Fix and Surface Preparation** |  | 5d | 2026-08-20 | 2026-08-26 | 29 | 0d |  |
| 35 | 7.3.3.1 | Preparation for painting throughout |  | 5d | 2026-08-20 | 2026-08-26 | 29 | 0d |  |
| 36 | 7.3.3.2 | Ceiling and wall repairs |  | 3d | 2026-08-20 | 2026-08-24 | 29 | 5d | 0d |
| 37 | 7.3.3.3 | Joinery grounds and supports installed |  | 2d | 2026-08-25 | 2026-08-26 | 36 | 5d | 0d |
| 38 | 7.3.3.4 | Preparation to existing vanity units |  | 2d | 2026-08-20 | 2026-08-21 | 29 | 67d | 0d |
| 39 | 7.3.3.5 | Application of microcement finishes |  | 3d | 2026-08-24 | 2026-08-26 | 38 | 67d |  |
| 40 | 7.3.4 | **Joinery** |  | 25d | 2026-08-06 | 2026-09-09 |  | 15d |  |
| 41 | 7.3.4.1 | Reclad all bars |  | 1w | 2026-08-06 | 2026-08-12 |  | 15d |  |
| 42 | 7.3.4.2 | Install new reception desk and tote booth |  | 2d | 2026-08-06 | 2026-08-07 |  | 80d |  |
| 43 | 7.3.4.3 | Reinstalled re-veneered wall panelling |  | 2d | 2026-09-08 | 2026-09-09 | 45FS+3d | 57d |  |
| 44 | 7.3.5 | **Flooring and Painting** |  | 15d | 2026-08-27 | 2026-09-16 |  | 0d |  |
| 45 | 7.3.5.1 | Paint all areas behind panelling |  | 1w | 2026-08-27 | 2026-09-02 | 35 | 0d |  |
| 46 | 7.3.5.2 | Painting throughout |  | 2w | 2026-09-03 | 2026-09-16 | 35, 45, 41 | 0d |  |
| 47 | 7.3.5.3 | Installation of all new floor finishes |  | 1w | 2026-08-27 | 2026-09-02 | 37 | 5d | 0d |
| 48 | 7.3.5.4 | Detailing at thresholds and interfaces |  | 1w | 2026-09-03 | 2026-09-09 | 47 | 5d |  |
| 49 | 7.3.6 | **Furniture, Lighting and Commissioning** |  | 9d? | 2026-09-17 | 2026-09-29 | 44 | 0d |  |
| 50 | 7.3.6.1 | Delivery and placement of furniture |  | 1d? | 2026-09-17 | 2026-09-17 |  | 0d |  |
| 51 | 7.3.6.2 | deep clean |  | 2d | 2026-09-18 | 2026-09-21 | 50 | 0d |  |
| 52 | 7.3.6.3 | Snagging and commissioning |  | 1w | 2026-09-22 | 2026-09-28 | 51 | 0d |  |
| 53 | 7.3.6.4 | Final Clean |  | 1d? | 2026-09-29 | 2026-09-29 | 52 | 0d |  |
| 54 | 7.3.7 | Reopening 1st floor | milestone | 0d | 2026-09-30 | 2026-09-30 | 53FS+1d | 0d |  |

| ID | WBS | Task | Duration | Start | Finish | Predecessors | Total slack | Free slack |
| --- | --- | --- | --- | --- | --- | --- | --- | --- |
| 55 | 7.4 | **Entrance Building Works** | 30d | 2026-08-07 | 2026-09-17 | 8 | 51d |  |
| 56 | 7.4.1 | Enabling Works | 1w | 2026-08-07 | 2026-08-13 | 8 | 51d | 0d |
| 57 | 7.4.2 | Structural Openings | 1w | 2026-08-14 | 2026-08-20 | 56 | 51d | 0d |
| 58 | 7.4.3 | Envelope and Framing Works | 1w | 2026-08-21 | 2026-08-27 | 57 | 51d | 0d |
| 59 | 7.4.4 | Glazing and Turnstile Installation | 1w | 2026-08-28 | 2026-09-03 | 58 | 51d | 0d |
| 60 | 7.4.5 | External Cladding | 1w | 2026-09-04 | 2026-09-10 | 59 | 51d | 0d |
| 61 | 7.4.6 | Signage and Completion | 1w | 2026-09-11 | 2026-09-17 | 60 | 51d |  |
| 62 | 7.5 | **Phase 2 Ground Floor Refurbishment** | 40d | 2026-10-01 | 2026-11-25 | 54 | 0d |  |
| 63 | 7.5.1 | **Site Preparation and Strip Out** | 5d | 2026-10-01 | 2026-10-07 |  | 0d |  |
| 64 | 7.5.1.1 | Remove carpets and redundant fittings | 2d | 2026-10-01 | 2026-10-02 |  | 0d |  |
| 65 | 7.5.1.2 | Remove redundant cladding around structures | 2d | 2026-10-05 | 2026-10-06 | 64 | 0d |  |
| 66 | 7.5.1.3 | Install hoarding and dust partitions | 1d | 2026-10-07 | 2026-10-07 | 65 | 0d |  |
| 67 | 7.5.1.4 | Isolate affected areas | 1d | 2026-10-07 | 2026-10-07 | 65 | 0d |  |
| 68 | 7.5.2 | **Demolition and Builders Works** | 5d | 2026-10-08 | 2026-10-14 | 63 | 0d |  |
| 69 | 7.5.2.1 | Cut back existing tote booth | 1d | 2026-10-08 | 2026-10-08 | 63 | 4d |  |
| 70 | 7.5.2.2 | Form new opening to hot food servery | 1d | 2026-10-08 | 2026-10-08 | 63 | 4d |  |
| 71 | 7.5.2.3 | Form new cleaner store door opening | 1d | 2026-10-08 | 2026-10-08 | 63 | 4d |  |
| 72 | 7.5.2.4 | Demolition of toilet block | 3d | 2026-10-08 | 2026-10-12 |  | 0d |  |
| 73 | 7.5.2.5 | Making good to drainage and pipework | 2d | 2026-10-13 | 2026-10-14 | 72 | 0d |  |
| 74 | 7.5.3 | **Structural and Framing Works** | 5d | 2026-10-15 | 2026-10-21 |  | 0d |  |
| 75 | 7.5.3.1 | Framing and builders works | 1w | 2026-10-15 | 2026-10-21 | 68 | 0d |  |
| 76 | 7.5.3.2 | Coordination of services modifications | 3d | 2026-10-15 | 2026-10-19 | 68 | 25d | 0d |
| 77 | 7.5.3.3 | Form new stage area | 2d | 2026-10-20 | 2026-10-21 | 76 | 25d |  |
| 78 | 7.5.4 | **Surface Preparation** | 10d | 2026-10-15 | 2026-10-28 |  | 0d |  |
| 79 | 7.5.4.1 | Preparation for painting throughout | 1w | 2026-10-15 | 2026-10-21 | 68 | 5d |  |
| 80 | 7.5.4.2 | Substrate preparation works | 2d | 2026-10-22 | 2026-10-23 | 75 | 0d |  |
| 81 | 7.5.4.3 | Microcement application to existing vanities | 3d | 2026-10-26 | 2026-10-28 | 80 | 0d |  |

| ID | WBS | Task | Type | Duration | Start | Finish | Predecessors | Total slack | Free slack |
| --- | --- | --- | --- | --- | --- | --- | --- | --- | --- |
| 82 | 7.5.5 | **Joinery** |  | 10d | 2026-10-29 | 2026-11-11 |  | 10d |  |
| 83 | 7.5.5.1 | Install all joinery items |  | 2w | 2026-10-29 | 2026-11-11 | 78 | 10d |  |
| 84 | 7.5.6 | **Lighting and Ceiling Works** |  | 5d | 2026-10-29 | 2026-11-04 |  | 0d |  |
| 85 | 7.5.6.1 | Lighting and ceilng workd |  | 1w | 2026-10-29 | 2026-11-04 | 78 | 0d |  |
| 86 | 7.5.7 | **Flooring Installation** |  | 10d | 2026-11-05 | 2026-11-18 | 84 | 0d |  |
| 87 | 7.5.7.1 | All flooring |  | 2w | 2026-11-05 | 2026-11-18 |  | 0d |  |
| 88 | 7.5.8 | **Signage, Decoration and Completion** |  | 5d | 2026-11-19 | 2026-11-25 | 86 | 0d |  |
| 89 | 7.5.8.1 | <New Task> |  | 1w | 2026-11-19 | 2026-11-25 |  | 0d |  |
| 90 | 7.6 | **External works** |  | 83d? | 2026-08-04 | 2026-11-26 |  | 1d |  |
| 91 | 7.6.1 | Form new entrance surround |  | 2w | 2026-08-04 | 2026-08-17 |  | 34d | 0d |
| 92 | 7.6.2 | Final external lighting adjustments |  | 3d | 2026-08-04 | 2026-08-06 |  | 81d |  |
| 93 | 7.6.3 | Replace remaining external signage |  | 1w | 2026-08-17 | 2026-08-21 | 21 | 70d |  |
| 94 | 7.6.4 | Complete all external painting works |  | 8w | 2026-08-18 | 2026-10-12 | 91 | 34d |  |
| 95 | 7.6.5 | Remove temporary works and hoarding |  | 1d? | 2026-11-26 | 2026-11-26 | 62 | 0d |  |
| 96 | 8 | Grand reopening | milestone | 0d | 2026-11-27 | 2026-11-27 | 95FS+1d | 0d |  |
